# Diagrama de Pert y Gantt-818

Schedule from MS Project, 2021-07-01 to 2021-11-27.

## Calendars

- Copia de Estándar: Mon-Sun 09:00-13:00, 15:00-19:00.

## Schedule

| ID | WBS | Task | Duration | Start | Finish | Predecessors | Total slack | Free slack |
| --- | --- | --- | --- | --- | --- | --- | --- | --- |
| 1 | 1 | **OBRA: REHABILITACIÓN DEL LOCAL ESCOLAR N°818, DISTRITO DE CATACAOS, PROVINCIA DE PIURA-PIURA** | 150d | 2021-07-01 | 2021-11-27 |  |  |  |
| 2 | 1.1 | **ESTRUCTURAS** | 145d | 2021-07-01 | 2021-11-22 |  | 0d |  |
| 3 | 1.1.1 | **CONSTRUCCIONES PROVISIONALES, TRABAJOS PRELIMINARES, DESMONTAJES Y DEMOLICIONES** | 145d | 2021-07-01 | 2021-11-22 |  | 0d |  |
| 4 | 1.1.1.1 | **CONSTRUCCIONES PROVISIONALES** | 145d | 2021-07-01 | 2021-11-22 |  | 0d |  |
| 5 | 1.1.1.1.1 | ALMACEN, OFICINA Y CASETA DE GUARDIANIA | 4d | 2021-07-01 | 2021-07-04 |  | 0d |  |
| 6 | 1.1.1.1.2 | ALQUILER DE SS.HH PROVISIONALES | 145d | 2021-07-01 | 2021-11-22 | 5SS | 5d |  |
| 7 | 1.1.1.1.3 | CERCO PROVISIONAL DE TRIPLAY | 4d | 2021-07-05 | 2021-07-08 | 5 | 142d |  |
| 8 | 1.1.1.1.4 | CARTEL DE IDENTIFICACION DE OBRA DE 2.40 X 3.60 m | 1d | 2021-07-01 | 2021-07-01 | 5SS | 0d |  |
| 9 | 1.1.1.1.5 | MOVILIZACION Y DESMOVILIZACION DE EQUIPOS Y MAQUINARIA | 4d | 2021-07-02 | 2021-07-05 | 8 | 145d |  |
| 10 | 1.1.1.1.6 | FLETE TERRESTRE | 120d | 2021-07-01 | 2021-10-28 | 5SS | 30d |  |
| 11 | 1.1.1.2 | **TRABAJOS PRELIMINARES** | 5d | 2021-07-05 | 2021-07-09 |  | 141d |  |
| 12 | 1.1.1.2.1 | TRAZO Y REPLANTEO PRELIMINAR | 5d | 2021-07-05 | 2021-07-09 | 5 | 141d |  |
| 13 | 1.1.1.3 | **DESMONTAJES Y DEMOLICIONES** | 8d | 2021-07-02 | 2021-07-09 |  | 0d |  |
| 14 | 1.1.1.3.1 | **DESMONTAJE** | 4d | 2021-07-02 | 2021-07-05 |  | 0d |  |
| 15 | 1.1.1.3.1.1 | DESMONTAJE DE VENTANAS DE FIERRO | 2d | 2021-07-02 | 2021-07-03 | 8 | 0d |  |
| 16 | 1.1.1.3.1.2 | DESMONTAJE DE PORTON METALICO | 1d | 2021-07-03 | 2021-07-03 | 15SS+1d | 0d |  |
| 17 | 1.1.1.3.1.3 | DESMONTAJE DE PUERTAS METALICAS | 1d | 2021-07-03 | 2021-07-03 | 16SS | 0d |  |
| 18 | 1.1.1.3.1.4 | DESMONTAJE DE ESTRUCTURA METALICA EN TECHOS-VIGAS Y VIGUETAS | 2d | 2021-07-04 | 2021-07-05 | 17 | 0d |  |
| 19 | 1.1.1.3.1.5 | DESMONTAJE DE COBERTURA : ASBESTO - CEMENTO, CALAMINON, CALAMINA | 2d | 2021-07-04 | 2021-07-05 | 17 | 145d |  |
| 20 | 1.1.1.3.1.6 | DESMONTAJE DE APARATOS SANITARIOS | 1d | 2021-07-04 | 2021-07-04 | 17 | 146d |  |
| 21 | 1.1.1.3.1.7 | DESMONTAJE DE LUMINARIAS | 1d | 2021-07-04 | 2021-07-04 | 17 | 146d |  |
| 22 | 1.1.1.3.2 | **DEMOLICIONES** | 4d | 2021-07-06 | 2021-07-09 |  | 0d |  |
| 23 | 1.1.1.3.2.1 | DEMOLICION DE SOBRECIMIENTO DE CONCRETO | 1d | 2021-07-06 | 2021-07-06 | 18 | 0d |  |
| 24 | 1.1.1.3.2.2 | DEMOLICION DE CIMIENTOS DE CONCRETO | 3d | 2021-07-07 | 2021-07-09 | 23 | 141d |  |
| 25 | 1.1.1.3.2.3 | DEMOLICION DE COLUMNAS Y VIGAS DE CONCRETO | 1d | 2021-07-07 | 2021-07-07 | 23 | 0d |  |
| 26 | 1.1.1.3.2.4 | DEMOLICION DE LOSA ALIGUERADA E=0.20m | 1d | 2021-07-07 | 2021-07-07 | 23 | 141d | 0d |
| 27 | 1.1.1.3.2.5 | DEMOLICION DE VEREDAS | 1d | 2021-07-08 | 2021-07-08 | 26 | 142d |  |
| 28 | 1.1.1.3.2.6 | DEMOLICION DE PISO DE CONCETO INC.FALSO PISO | 2d | 2021-07-07 | 2021-07-08 | 26SS | 141d | 0d |
| 29 | 1.1.1.3.2.7 | DEMOLICION DE PATIO - MATERIAL DE CONCRETO | 2d | 2021-07-08 | 2021-07-09 | 28SS+1d | 141d |  |
| 30 | 1.1.1.3.2.8 | DEMOLICION MUROS DE LADRILLO | 2d | 2021-07-07 | 2021-07-08 | 25SS | 0d |  |
| 31 | 1.1.1.3.2.9 | DEMOLICION DE ESTRUCTURA - MATERIAL DE CONCRETO | 1d | 2021-07-07 | 2021-07-07 | 30SS | 0d |  |
| 32 | 1.1.1.3.2.10 | ELIMINACION DE MATERIAL EXCEDENTE CON MAQUINARIA | 2d | 2021-07-07 | 2021-07-08 | 31SS | 0d |  |

| ID | WBS | Task | Duration | Start | Finish | Predecessors | Total slack | Free slack |
| --- | --- | --- | --- | --- | --- | --- | --- | --- |
| 33 | 1.1.2 | **SEGURIDAD Y SALUD** | 135d | 2021-07-01 | 2021-11-12 |  | 15d |  |
| 34 | 1.1.2.1 | **PLAN PARA VIGILANCIA, PREVENCION Y CONTROL DE COVID 19 PARA EL TRABAJO** | 135d | 2021-07-01 | 2021-11-12 |  | 15d |  |
| 35 | 1.1.2.1.1 | EQUIPOS DE PROTECCIÓN INDIVIDUAL | 135d | 2021-07-01 | 2021-11-12 | 5SS | 15d | 0d |
| 36 | 1.1.2.1.2 | EQUIPOS DE PROTECCIÓN COLECTIVA | 135d | 2021-07-01 | 2021-11-12 | 35SS | 15d | 0d |
| 37 | 1.1.2.1.3 | SEÑALIZACION TEMPORAL DE SEGURIDAD | 135d | 2021-07-01 | 2021-11-12 | 36SS | 15d | 0d |
| 38 | 1.1.2.1.4 | CAPACITACIÓN EN SEGURIDAD Y SALUD | 135d | 2021-07-01 | 2021-11-12 | 37SS | 15d | 0d |
| 39 | 1.1.2.1.5 | MECANISMOS TECNICOS, ADMINISTRATIVOS Y EQUIPAMIENTO | 135d | 2021-07-01 | 2021-11-12 | 38SS | 15d | 0d |
| 40 | 1.1.2.2 | **ELABORACION, IMPLEMENTACION Y ADMINISTRACION DEL PLAN DE SEGURIDAD Y SALUD EN EL TRABAJO** | 135d | 2021-07-01 | 2021-11-12 |  | 15d |  |
| 41 | 1.1.2.2.1 | ELABORACION DE PLAN DE VIGILANCIA, PREVENCION Y CONTROL DE COVID 19 | 135d | 2021-07-01 | 2021-11-12 | 39SS | 15d | 0d |
| 42 | 1.1.2.2.2 | LIMPIEZA Y DESINFECCION DE CENTRO DE TRABAJO | 135d | 2021-07-01 | 2021-11-12 | 41SS | 15d | 0d |
| 43 | 1.1.2.2.3 | SENSIBILIZACION DE LA PREVENCION DEL CONTAGIO EN EL CENTRO DE TRABAJO | 135d | 2021-07-01 | 2021-11-12 | 42SS | 15d | 0d |
| 44 | 1.1.2.2.4 | EVALUACION DE LA CONDICION DE SALUD DEL TRABAJADOR PREVIO AL REGRESO E INCORPORACION AL CENTRO DE TRABAJO | 135d | 2021-07-01 | 2021-11-12 | 43SS | 15d | 0d |
| 45 | 1.1.2.2.5 | LIAVADO Y DESINFECCION DE MANOS OBLIGATORIO | 135d | 2021-07-01 | 2021-11-12 | 44SS | 15d | 0d |
| 46 | 1.1.2.2.6 | MEDIDAS PREVENTIVAS DE APLICACION COLECTIVA | 135d | 2021-07-01 | 2021-11-12 | 45SS | 15d | 0d |
| 47 | 1.1.2.2.7 | MEDIDAS DE PROTECCION PERSONAL (30 PERSONAS) | 135d | 2021-07-01 | 2021-11-12 | 46SS | 15d |  |
| 48 | 1.1.3 | **MOVIMIENTO DE TIERRAS** | 15d | 2021-07-09 | 2021-07-23 |  | 0d |  |
| 49 | 1.1.3.1 | CORTE DE TERRENO CON MAQUINARIA | 3d | 2021-07-09 | 2021-07-11 | 32 | 0d |  |
| 50 | 1.1.3.2 | NIVELACIÓN,Y COMPACTADO DE TERRENO | 3d | 2021-07-12 | 2021-07-14 | 49 | 0d |  |
| 51 | 1.1.3.3 | EXCAVACION PARA PLATEA DE CIMENTACIÓN | 3d | 2021-07-14 | 2021-07-16 | 50FS-1d | 0d |  |
| 52 | 1.1.3.4 | EXCAVACIÓN PARA VIGA DE CIMENTACIÓN | 1d | 2021-07-14 | 2021-07-14 | 51SS | 136d |  |
| 53 | 1.1.3.5 | EXCAVACION DE CIMIENTOS CORRIDOS | 1d | 2021-07-14 | 2021-07-14 | 51SS | 136d |  |
| 54 | 1.1.3.6 | EXCAVACION DE ZANJAS PARA ZAPATAS | 2d | 2021-07-14 | 2021-07-15 | 51SS | 0d |  |
| 55 | 1.1.3.7 | RELLENO COMPACTADO C/EQUIPO, MAT/AFIRMADO | 4d | 2021-07-16 | 2021-07-19 | 54 | 0d |  |
| 56 | 1.1.3.8 | RELLENO COMPACTADO C/EQUIPO, MAT/PROPIO SELCCIONADO | 4d | 2021-07-20 | 2021-07-23 | 55 | 107d | 0d |
| 57 | 1.1.3.9 | ELIMINACION DE MATERIAL EXCEDENTE CON MAQUINARIA | 3d | 2021-07-16 | 2021-07-18 | 51FS-1d | 132d |  |

| ID | WBS | Task | Duration | Start | Finish | Predecessors | Total slack | Free slack |
| --- | --- | --- | --- | --- | --- | --- | --- | --- |
| 58 | 1.1.4 | **OBRAS DE CONCRETO SIMPLE** | 88d | 2021-07-20 | 2021-10-15 |  | 0d |  |
| 59 | 1.1.4.1 | **SOLADOS** | 4d | 2021-07-20 | 2021-07-23 |  | 126d |  |
| 60 | 1.1.4.1.1 | SOLADO DE CONCRETO C:H 1:12 e=0.10m | 4d | 2021-07-20 | 2021-07-23 | 55 | 126d | 0d |
| 61 | 1.1.4.2 | **CIMIENTOS Y SUB CIMIENTOS** | 1d | 2021-07-24 | 2021-07-24 |  | 126d |  |
| 62 | 1.1.4.2.1 | CIMIENTO CORRIDO C:H 1:10 + 30% P.G | 1d | 2021-07-24 | 2021-07-24 | 60 | 126d |  |
| 63 | 1.1.4.3 | **FALSO PISO** | 4d | 2021-07-24 | 2021-07-27 |  | 123d |  |
| 64 | 1.1.4.3.1 | FALSO PISO MEZCLA 1:8 CEMENTO HORMIGON E=4'' | 4d | 2021-07-24 | 2021-07-27 | 56 | 123d |  |
| 65 | 1.1.4.4 | **OBRAS DE CONCRETO ARMADO** | 88d | 2021-07-20 | 2021-10-15 |  | 0d |  |
| 66 | 1.1.4.4.1 | **ZAPATAS** | 4d | 2021-07-20 | 2021-07-23 |  | 0d |  |
| 67 | 1.1.4.4.1.1 | CONCRETO EN ZAPATAS f´c = 210 kg/cm2 | 2d | 2021-07-22 | 2021-07-23 | 68 | 127d |  |
| 68 | 1.1.4.4.1.2 | ACERO CORRUGADO FY= 4200 kg/cm2 GRADO 60 EN ZAPATAS | 2d | 2021-07-20 | 2021-07-21 | 55 | 0d |  |
| 69 | 1.1.4.4.2 | **VIGA DE CIMENTACION** | 8d | 2021-07-22 | 2021-07-29 |  | 0d |  |
| 70 | 1.1.4.4.2.1 | CONCRETO EN VIGAS DE CIMENTACIÓN f´c = 210 kg/cm2 | 1d | 2021-07-28 | 2021-07-28 | 71 | 122d |  |
| 71 | 1.1.4.4.2.2 | ENCOFRADO Y DESENCOFRADO NORMAL P/VIGAS DE CIMENTACIÓN | 2d | 2021-07-26 | 2021-07-27 | 72SS+4d | 122d | 0d |
| 72 | 1.1.4.4.2.3 | ACERO CORRUGADO FY= 4200 kg/cm2 GRADO 60 EN VIGAS DE CIMENTACIÓN | 8d | 2021-07-22 | 2021-07-29 | 68 | 0d |  |
| 73 | 1.1.4.4.3 | **SOBRECIMIENTO REFORZADO** | 20d | 2021-08-09 | 2021-08-28 |  | 0d |  |
| 74 | 1.1.4.4.3.1 | CONCRETO PARA SOBRECIMEINTO REFORZADO F'C 175 KG/CM2 | 8d | 2021-08-21 | 2021-08-28 | 75 | 0d |  |
| 75 | 1.1.4.4.3.2 | ENCOFRADO Y DESENCOFRADO NORMAL EN SOBRECIMIENTO REFORZADO | 8d | 2021-08-13 | 2021-08-20 | 76SS+4d | 0d |  |
| 76 | 1.1.4.4.3.3 | ACERO FY= 4200 kg/cm2 GRADO 60EN SOBRECIMIENTO REFORZADO | 6d | 2021-08-09 | 2021-08-14 | 103 | 0d |  |
| 77 | 1.1.4.4.4 | **COLUMNAS** | 33d | 2021-08-09 | 2021-09-10 |  | 34d |  |
| 78 | 1.1.4.4.4.1 | CONCRETO EN COLUMNAS F'C=210KG/CM2 | 20d | 2021-08-22 | 2021-09-10 | 79SS+6d | 34d | 0d |
| 79 | 1.1.4.4.4.2 | ENCOFRADO Y DESENCOFRADO NORMAL EN COLUMNAS | 20d | 2021-08-16 | 2021-09-04 | 80SS+7d | 34d | 0d |
| 80 | 1.1.4.4.4.3 | ACERO FY= 4200 kg/cm2 GRADO 60EN COLUMNAS | 14d | 2021-08-09 | 2021-08-22 | 103 | 34d | 0d |
| 81 | 1.1.4.4.5 | **VIGAS** | 19d | 2021-08-30 | 2021-09-17 |  | 34d |  |
| 82 | 1.1.4.4.5.1 | CONCRETO EN VIGAS F´c = 210 kg/cm2 | 8d | 2021-09-10 | 2021-09-17 | 83FS-5d | 43d | 0d |
| 83 | 1.1.4.4.5.2 | ENCOFRADO Y DESENCOFRADO NORMAL EN VIGAS | 10d | 2021-09-05 | 2021-09-14 | 84SS+6d | 43d | 0d |
| 84 | 1.1.4.4.5.3 | ACERO FY= 4200 kg/cm2 GRADO 60 EN VIGAS | 12d | 2021-08-30 | 2021-09-10 | 78FS-12d | 34d | 0d |

| ID | WBS | Task | Duration | Start | Finish | Predecessors | Total slack | Free slack |
| --- | --- | --- | --- | --- | --- | --- | --- | --- |
| 85 | 1.1.4.4.6 | **COLUMNAS DE CONFINAMIENTO** | 26d | 2021-09-18 | 2021-10-13 |  | 43d |  |
| 86 | 1.1.4.4.6.1 | CONCRETO EN COLUMNAS DE CONFINAMIENTO F'C=175 KG/CM2 | 12d | 2021-10-02 | 2021-10-13 | 87SS+8d | 43d | 0d |
| 87 | 1.1.4.4.6.2 | ENCOFRADO Y DESENCOFRADO NORMAL EN COLUMNAS DE CONFINAMIENTO | 12d | 2021-09-24 | 2021-10-05 | 88SS+6d | 43d | 0d |
| 88 | 1.1.4.4.6.3 | ACERO FY= 4200 kg/cm2 GRADO 60 EN COLUMNAS DE CONFINAMIENTO | 8d | 2021-09-18 | 2021-09-25 | 82 | 43d | 0d |
| 89 | 1.1.4.4.7 | **VIGAS DE CONFINAMIENTO** | 14d | 2021-10-02 | 2021-10-15 |  | 43d |  |
| 90 | 1.1.4.4.7.1 | CONCRETO EN VIGAS DE CONFINAMIENTO F´c = 175 kg/cm2 | 6d | 2021-10-10 | 2021-10-15 | 91 | 43d |  |
| 91 | 1.1.4.4.7.2 | ENCOFRADO Y DESENCOFRADO NORMAL EN VIGAS DE CONFINAMIENTO | 6d | 2021-10-04 | 2021-10-09 | 92SS+2d | 43d | 0d |
| 92 | 1.1.4.4.7.3 | ACERO FY= 4200 kg/cm2 GRADO 60 EN VIGAS DE CONFINAMIENTO | 4d | 2021-10-02 | 2021-10-05 | 86SS | 43d | 0d |
| 93 | 1.1.4.4.8 | **LOSAS ALIGERADAS** | 15d | 2021-09-07 | 2021-09-21 |  | 34d |  |
| 94 | 1.1.4.4.8.1 | CONCRETO EN LOSA ALIGERADA f'c=210 kg/cm2 | 4d | 2021-09-18 | 2021-09-21 | 95FS-2d | 34d | 0d |
| 95 | 1.1.4.4.8.2 | ENCOFRADO Y DESENCOFRADO NORMAL EN LOSA ALIGERADA | 12d | 2021-09-08 | 2021-09-19 | 97SS+1d | 34d | 0d |
| 96 | 1.1.4.4.8.3 | LADRILLO HUECO DE ARCILLA h = 15 X30X30 cm PARA TECHO ALIGERADO | 4d | 2021-09-18 | 2021-09-21 | 95SS+10d | 67d |  |
| 97 | 1.1.4.4.8.4 | ACERO FY= 4200 kg/cm2 GRADO 60 EN LOSAS ALIGERADAS | 4d | 2021-09-07 | 2021-09-10 | 84FS-4d | 34d | 0d |
| 98 | 1.1.4.4.9 | **CISTERNA** | 6d | 2021-08-09 | 2021-08-14 |  | 94d |  |
| 99 | 1.1.4.4.9.1 | CONCRETO EN CISTERNA F'C 210KG/CM2 | 1d | 2021-08-14 | 2021-08-14 | 100 | 94d | 0d |
| 100 | 1.1.4.4.9.2 | ENCOFRADO Y DESENCOFRADO NORMAL EN CISTERNA | 3d | 2021-08-11 | 2021-08-13 | 101 | 94d | 0d |
| 101 | 1.1.4.4.9.3 | ACERO FY= 4200 kg/cm2 GRADO 60 EN CISTERNA | 2d | 2021-08-09 | 2021-08-10 | 103 | 94d | 0d |
| 102 | 1.1.4.4.10 | **PLATEA DE CIMENTACIÓN** | 14d | 2021-07-26 | 2021-08-08 |  | 0d |  |
| 103 | 1.1.4.4.10.1 | CONCRETO EN PLATEA DE CIMENTACION f'c=210 kg/cm2 | 4d | 2021-08-05 | 2021-08-08 | 104 | 0d |  |
| 104 | 1.1.4.4.10.2 | ACERO FY= 4200 kg/cm2 GRADO 60 EN PLATEA DE CIMENTACIÓN | 10d | 2021-07-26 | 2021-08-04 | 72SS+4d | 0d |  |
| 105 | 1.1.4.4.11 | **ESCALERA** | 7d | 2021-08-15 | 2021-08-21 |  | 98d |  |
| 106 | 1.1.4.4.11.1 | CONCRETO EN ESCALERA f´c = 210 kg/cm2 | 1d | 2021-08-21 | 2021-08-21 | 107 | 98d |  |
| 107 | 1.1.4.4.11.2 | ENCOFRADO Y DESENCOFRADO NORMAL EN ESCALERA | 4d | 2021-08-17 | 2021-08-20 | 108 | 98d | 0d |
| 108 | 1.1.4.4.11.3 | ACERO FY= 4200 kg/cm2 GRADO 60 EN ESCALERA | 2d | 2021-08-15 | 2021-08-16 | 99 | 98d | 0d |

| ID | WBS | Task | Duration | Start | Finish | Predecessors | Total slack | Free slack |
| --- | --- | --- | --- | --- | --- | --- | --- | --- |
| 109 | 1.1.4.4.12 | **PARAPETOS** | 6d | 2021-09-18 | 2021-09-23 |  | 65d |  |
| 110 | 1.1.4.4.12.1 | CONCRETO EN PARAPETO f'c= 175 kg/cm2 | 2d | 2021-09-22 | 2021-09-23 | 111 | 65d |  |
| 111 | 1.1.4.4.12.2 | ENCOFRADO Y DESENCOFRADO NORMAL EN PARAPETO f'c= 175 kg/cm2 | 2d | 2021-09-20 | 2021-09-21 | 112 | 65d | 0d |
| 112 | 1.1.4.4.12.3 | ACERO FY= 4200 kg/cm2 GRADO 60 EN PARAPETO | 2d | 2021-09-18 | 2021-09-19 | 82 | 65d | 0d |
| 113 | 1.2 | **ARQUITECTURA** | 105d | 2021-08-15 | 2021-11-27 |  | 0d |  |
| 114 | 1.2.1 | **MUROS Y TABIQUES DE ALBAÑILERIA** | 30d | 2021-08-29 | 2021-09-27 |  | 0d |  |
| 115 | 1.2.1.1 | MURO DE LADRILLO KK 18 HUECOS SOGA | 25d | 2021-08-29 | 2021-09-22 | 74 | 0d |  |
| 116 | 1.2.1.2 | MURO DE LADRILLO KK 18 HUECOS CABEZA | 8d | 2021-09-13 | 2021-09-20 | 115SS+15d | 68d |  |
| 117 | 1.2.1.3 | ACERO DE AMARRE | 25d | 2021-09-03 | 2021-09-27 | 115SS+5d | 61d |  |
| 118 | 1.2.2 | **REVOQUES Y REVESTIMIENTOS** | 82d | 2021-08-15 | 2021-11-04 |  | 23d |  |
| 119 | 1.2.2.1 | TARRAJEO PRIMARIO EN MUROS MEZCLA C:A 1:5 | 8d | 2021-09-13 | 2021-09-20 | 115SS+15d | 0d |  |
| 120 | 1.2.2.2 | TARRAJEO EN MUROS INTERIORES MEZCLA C:A 1:4, E=1.5CM | 16d | 2021-09-22 | 2021-10-07 | 94 | 46d | 0d |
| 121 | 1.2.2.3 | TARRAJEO EN MUROS EXTERIORES MEZCLA C:A 1:4, E=1.5CM | 14d | 2021-09-16 | 2021-09-29 | 119SS+3d | 0d |  |
| 122 | 1.2.2.4 | TARRAJEO EN COLUMNAS, MEZCLA C:A 1:4, E=1.5CM | 10d | 2021-09-26 | 2021-10-05 | 121SS+10d | 0d |  |
| 123 | 1.2.2.5 | TARRAJEO EN COLUMNETAS, MEZCLA C:A 1:4, E=1.5CM | 6d | 2021-10-04 | 2021-10-09 | 122SS+8d | 0d |  |
| 124 | 1.2.2.6 | TARRAJEO EN DINTELES, MEZCLA C:A 1:4, E=1.5CM | 2d | 2021-10-10 | 2021-10-11 | 123 | 0d |  |
| 125 | 1.2.2.7 | TARRAJEO EN VIGAS, MEZCLA C:A 1:4, E=1.5CM | 6d | 2021-10-12 | 2021-10-17 | 124 | 0d |  |
| 126 | 1.2.2.8 | TARRAJEO DE FALSA COLUMNA DE EVACUACIÓN DE 0.15X0.15M | 1d | 2021-10-18 | 2021-10-18 | 125 | 40d |  |
| 127 | 1.2.2.9 | TARRAJEO IMPERMEABLIZANTE C:A 1:4 - CISTERNA | 1d | 2021-08-15 | 2021-08-15 | 99 | 94d | 0d |
| 128 | 1.2.2.10 | TARRAJEO IMPERMEABLIZANTE C:A 1:4 - CANALETA PLUVIAL EN PISO | 1d | 2021-08-16 | 2021-08-16 | 127 | 99d | 0d |
| 129 | 1.2.2.11 | VESTIDURA DE DERRAMES MEZCLA C:A 1:5 | 20d | 2021-10-06 | 2021-10-25 | 122 | 23d | 0d |
| 130 | 1.2.2.12 | FORJADO DE FONDO DE ESCALERA | 1d | 2021-08-17 | 2021-08-17 | 128 | 99d | 0d |
| 131 | 1.2.2.13 | FORJADO DE DESCANSOS DE ESCALERA | 1d | 2021-08-18 | 2021-08-18 | 130 | 99d | 0d |
| 132 | 1.2.2.14 | FORJADO DE PASOS Y CONTRAPASOS DE ESCALERA | 2d | 2021-08-19 | 2021-08-20 | 131 | 99d |  |
| 133 | 1.2.2.15 | BRUÑAS DE 1 X 1 cm | 20d | 2021-10-16 | 2021-11-04 | 129SS+10d | 23d |  |

| ID | WBS | Task | Duration | Start | Finish | Predecessors | Total slack | Free slack |
| --- | --- | --- | --- | --- | --- | --- | --- | --- |
| 134 | 1.2.3 | **CIELORRASOS** | 10d | 2021-09-22 | 2021-10-01 |  | 34d |  |
| 135 | 1.2.3.1 | CIELORRASO CON MEZCLA DE CEMENTO-ARENA 1:5 | 10d | 2021-09-22 | 2021-10-01 | 94 | 34d | 0d |
| 136 | 1.2.4 | **PISOS Y PAVIMENTOS** | 34d | 2021-10-02 | 2021-11-04 |  | 23d |  |
| 137 | 1.2.4.1 | **PISOS** | 34d | 2021-10-02 | 2021-11-04 |  | 23d |  |
| 138 | 1.2.4.1.1 | CONTRAPISO C:A 1:5 e=40mm | 6d | 2021-10-02 | 2021-10-07 | 135 | 34d | 0d |
| 139 | 1.2.4.1.2 | PISO DE CEMENTO SEMIPULIDO BRUÑADO E=5 CM | 1d | 2021-10-08 | 2021-10-08 | 138 | 34d | 0d |
| 140 | 1.2.4.1.3 | PISO DE PORCELANATO 0.60x0.60 m DE ALTO TRANSITO, INCLUYE FRAGUADO | 14d | 2021-10-18 | 2021-10-31 | 125 | 10d | 0d |
| 141 | 1.2.4.1.4 | ENCHAPE DESCANSO DE ESCALERA CON PORCELANATO 0.60x0.60 m DE ALTO TRANSITO, INCLUYE FRAGUADO | 2d | 2021-11-01 | 2021-11-02 | 140 | 23d | 0d |
| 142 | 1.2.4.1.5 | ENCHAPE PASOS Y CONTRAPASOS DE ESCALERA CON PORCELANATO DE ALTO TRANSITO, INCLUYE FRAGUADO | 2d | 2021-11-03 | 2021-11-04 | 141 | 23d |  |
| 143 | 1.2.4.2 | **VEREDAS** | 9d | 2021-10-09 | 2021-10-17 |  | 34d |  |
| 144 | 1.2.4.2.1 | VEREDA DE CONCRETO 4''. f'c=175 kg/cm2, ACABADO FROTACHADAO, INCL. ENCOFRADO | 3d | 2021-10-09 | 2021-10-11 | 139 | 34d | 0d |
| 145 | 1.2.4.2.2 | VEREDA DE CONCRETO 4''. f'c=175 kg/cm2, ACABADO SEMIPULIDO Y BRUÑADO, INCL. ENCOFRADO | 4d | 2021-10-12 | 2021-10-15 | 144 | 34d | 0d |
| 146 | 1.2.4.2.3 | UÑA DE CONCRETO f'c=175 kg/cm2 | 1d | 2021-10-15 | 2021-10-15 | 145SS+3d | 43d |  |
| 147 | 1.2.4.2.4 | CURADO DE CONCRETO EN VEREDAS | 2d | 2021-10-16 | 2021-10-17 | 145 | 34d | 0d |
| 148 | 1.2.4.3 | **PATIOS** | 5d | 2021-10-18 | 2021-10-22 |  | 34d |  |
| 149 | 1.2.4.3.1 | LOSA DE CONCRETO F'C =175KG /CM2, E=6'', ACABADO FROTACHADO, INCLUYE INCL ENCOFRADO, EN PATIOS | 3d | 2021-10-18 | 2021-10-20 | 147 | 34d | 0d |
| 150 | 1.2.4.3.2 | UÑA DE CONCRETO f'c=175 kg/cm2 | 1d | 2021-10-21 | 2021-10-21 | 149 | 34d | 0d |
| 151 | 1.2.4.3.3 | CURADO DE CONCRETO PATIOS | 1d | 2021-10-22 | 2021-10-22 | 150 | 34d | 0d |
| 152 | 1.2.4.4 | **RAMPAS** | 2d | 2021-10-23 | 2021-10-24 |  | 34d |  |
| 153 | 1.2.4.4.1 | RAMPA DE CONCRETO FC 175 KG/CM2, E=4", ACABADO FROTACHADO, INC ENCOFRADO | 1d | 2021-10-23 | 2021-10-23 | 151 | 34d | 0d |
| 154 | 1.2.4.4.2 | UÑA DE CONCRETO f'c=175 kg/cm2 | 1d | 2021-10-23 | 2021-10-23 | 153SS | 34d | 0d |
| 155 | 1.2.4.4.3 | CURADO DE CONCRETO EN RAMPAS | 1d | 2021-10-24 | 2021-10-24 | 154 | 34d |  |
| 156 | 1.2.5 | **ZOCALOS** | 8d | 2021-10-28 | 2021-11-04 |  | 10d |  |
| 157 | 1.2.5.1 | ZOCALO PORCELANATO 0.60X0.60 M, INCLUYE FRAGUADO | 8d | 2021-10-28 | 2021-11-04 | 140SS+10d | 10d | 0d |

| ID | WBS | Task | Duration | Start | Finish | Predecessors | Total slack | Free slack |
| --- | --- | --- | --- | --- | --- | --- | --- | --- |
| 158 | 1.2.6 | **CONTRAZOCALOS** | 9d | 2021-11-05 | 2021-11-13 |  | 10d |  |
| 159 | 1.2.6.1 | CONTRAZOCALO DE CEMENTO PULIDO h=0.20 m E=1.5CM. | 1d | 2021-11-13 | 2021-11-13 | 160 | 14d |  |
| 160 | 1.2.6.2 | CONTRAZOCALO DE PORCELANATO DE 60X60 CM DE COLOR, H=10CM | 8d | 2021-11-05 | 2021-11-12 | 157 | 10d | 0d |
| 161 | 1.2.7 | **ESTRUCTURAS METALICAS** | 24d | 2021-10-18 | 2021-11-10 |  | 0d |  |
| 162 | 1.2.7.1 | COBERTURA CON PLANCHA DE FIBRA VEGETALCLASSIC ROJO (INC.ESTRUCTURA DE SOPORTE METALICA)-MODULO 01 Y 02 | 12d | 2021-10-18 | 2021-10-29 | 125 | 0d |  |
| 163 | 1.2.7.2 | COBERTURA CON PLANCHA DE FIBRA VEGETALCLASSIC ROJO (INC.ESTRUCTURA DE SOPORTE METALICA) - PATIO DE FORMACION Y T.E. | 12d | 2021-10-30 | 2021-11-10 | 162 | 0d |  |
| 164 | 1.2.8 | **CARPINTERIA DE MADERA** | 14d | 2021-10-30 | 2021-11-12 |  | 0d |  |
| 165 | 1.2.8.1 | PUERTA MACHIMBRADA CON MARCOS DE MADERA CEDRO DE 2''X4'', DE UNA HOJA DE 90° | 14d | 2021-10-30 | 2021-11-12 | 162 | 0d |  |
| 166 | 1.2.8.2 | PUERTA MACHIMBRADA CON MARCOS DE MADERA CEDRO DE 2''X4'', DE UNA HOJA DE 180° CON VISOR, INCLUYE VIDRIO | 6d | 2021-11-07 | 2021-11-12 | 165SS+8d | 0d |  |
| 167 | 1.2.9 | **CARPINTERIA METALICA** | 17d | 2021-11-10 | 2021-11-26 |  | 1d |  |
| 168 | 1.2.9.1 | CANALETA P/EVACUACIÓN PLUVIAL EN COBERTURA DE MODULOS | 4d | 2021-11-10 | 2021-11-13 | 163FS-1d | 2d | 0d |
| 169 | 1.2.9.2 | ESTRUCTURA METALICA PARA SOPORTE | 2d | 2021-11-16 | 2021-11-17 | 176 | 2d | 0d |
| 170 | 1.2.9.3 | PASAMANO DE FIERRO G° Ø2'' | 4d | 2021-11-18 | 2021-11-21 | 169 | 2d | 0d |
| 171 | 1.2.9.4 | AGAGARRE PARA DISCAPACITADOS | 4d | 2021-11-20 | 2021-11-23 | 170SS+2d | 2d | 0d |
| 172 | 1.2.9.5 | MARCO Y TAPA DE FIERRO - CISTERNA Y CUARTO INSPECC. T.E. | 2d | 2021-11-24 | 2021-11-25 | 171 | 2d | 0d |
| 173 | 1.2.9.6 | TAPAJUNTA METALICA ENTRE MODULOS (VERTICAL) | 4d | 2021-11-23 | 2021-11-26 | 172SS-1d | 1d | 0d |
| 174 | 1.2.9.7 | CANTONERA DE ALUMINIO 47X27MM | 4d | 2021-11-22 | 2021-11-25 | 173SS-1d | 2d | 0d |
| 175 | 1.2.9.8 | TAPAJUNTA METALICA EN PISOS | 2d | 2021-11-23 | 2021-11-24 | 174SS+1d | 3d |  |
| 176 | 1.2.9.9 | SUMINISTRO E INSTALACIÓN DE PUERTA Y PORTON DE INGRESO PRINCIPAL, SEGÚN PLANO | 2d | 2021-11-14 | 2021-11-15 | 168 | 2d | 0d |
| 177 | 1.2.9.10 | SUMINISTRO E INSTALACIÓN DE ENCUENTRO METALICO ENTRE SOBRETECHO Y PARAPETO | 2d | 2021-11-16 | 2021-11-17 | 176 | 9d | 0d |
| 178 | 1.2.9.11 | ESCALERA DE GATO | 1d | 2021-11-18 | 2021-11-18 | 177 | 9d |  |
| 179 | 1.2.10 | **CERRAJERIA** | 7d | 2021-11-13 | 2021-11-19 |  | 8d |  |
| 180 | 1.2.10.1 | CERRADURA CON MANIJA | 3d | 2021-11-16 | 2021-11-18 | 182 | 8d | 0d |
| 181 | 1.2.10.2 | CERRADURA DE TRES GOLPES PARA PUERTAS TIPO PARCHE | 1d | 2021-11-19 | 2021-11-19 | 180 | 8d |  |
| 182 | 1.2.10.3 | BISAGRA CAPUCHINAS ALUMINIZADA DE 3½" X 3½" | 3d | 2021-11-13 | 2021-11-15 | 166 | 8d | 0d |

| ID | WBS | Task | Duration | Start | Finish | Predecessors | Total slack | Free slack |
| --- | --- | --- | --- | --- | --- | --- | --- | --- |
| 183 | 1.2.11 | **VIDRIOS, CRISTALES Y SIMILARES** | 12d | 2021-11-16 | 2021-11-27 |  | 0d |  |
| 184 | 1.2.11.1 | SUMINISTRO E INSTALACIÓN DE VENTANA DE ALUMINIO CON VIDRIO CRUDO 6MM INCOLORO CON LAMINA DE SEGURIDAD DE 4 MICRAS (PROYECTANTE-CORREDIZA) Y PROTECTOR DE ALUMINIO | 6d | 2021-11-16 | 2021-11-21 | 166FS+3d | 0d |  |
| 185 | 1.2.11.2 | SUMINISTRO E INSTALACIÓN DE VENTANA DE ALUMINIO CON VIDRIO CRUDO 6MM INCOLORO CON LAMINA DE SEGURIDAD DE 4 MICRAS (PROYECTANTE) Y PROTECTOR DE ALUMINIO | 5d | 2021-11-19 | 2021-11-23 | 184SS+3d | 0d |  |
| 186 | 1.2.11.3 | SUMINISTRO E INSTALACIÓN DE PROTECTOR DE SEGURIDAD SOBRE PARAPETO, DE ALUMINIO C/POLICARBONATO E=6MM | 4d | 2021-11-24 | 2021-11-27 | 185 | 0d |  |
| 187 | 1.2.12 | **PINTURAS** | 18d | 2021-11-05 | 2021-11-22 |  | 0d |  |
| 188 | 1.2.12.1 | PINTURA LATEX PARA CIELO RASO 2 MANOS | 6d | 2021-11-05 | 2021-11-10 | 163SS+6d | 0d |  |
| 189 | 1.2.12.2 | PINTURA OLEO MATE EN INTERIORES DOS MANOS | 8d | 2021-11-11 | 2021-11-18 | 188 | 0d |  |
| 190 | 1.2.12.3 | PINTURA OLEO MATE EN EXTERIORES DOS MANOS | 6d | 2021-11-17 | 2021-11-22 | 189FS-2d | 0d |  |
| 191 | 1.2.13 | **JUNTAS** | 14d | 2021-10-10 | 2021-10-23 |  | 35d |  |
| 192 | 1.2.13.1 | JUNTA SISMICA DE 1" CON ESPUMA PLASTICA | 3d | 2021-10-10 | 2021-10-12 | 123 | 46d |  |
| 193 | 1.2.13.2 | JUNTA ASFALTICA DE 1" CON MORTERO ASFALTICO-ARENA 1:4 | 1d | 2021-10-23 | 2021-10-23 | 151 | 35d |  |
| 194 | 1.2.14 | **VARIOS** | 50d | 2021-10-08 | 2021-11-26 |  | 1d |  |
| 195 | 1.2.14.1 | ESTRUCTURA METÁLICA C/BASE MADERA | 1d | 2021-11-14 | 2021-11-14 | 168 | 13d |  |
| 196 | 1.2.14.2 | MESADA DE CONCRETO (INC. CONTRAPISO, ENCHAPE Y ACERO) | 3d | 2021-10-08 | 2021-10-10 | 120 | 46d | 0d |
| 197 | 1.2.14.3 | PIZARRA ACRILICA (1.20X4.80M) INCLUYE MARCO DE ALUMINIO (SOPORTE Y FIJACIÓN) | 3d | 2021-11-19 | 2021-11-21 | 189 | 6d |  |
| 198 | 1.2.14.4 | ESTRUCTURA DE MELAMINA | 2d | 2021-10-11 | 2021-10-12 | 196 | 46d |  |
| 199 | 1.2.14.5 | PISO DE POLIPROPILENO PARA PATIO DE ÁREA COMÚN | 1d | 2021-11-01 | 2021-11-01 | 140 | 26d |  |
| 200 | 1.2.14.6 | ESCUDO NACIONAL PINTADO EN PORTADA | 1d | 2021-11-18 | 2021-11-18 | 169 | 5d | 0d |
| 201 | 1.2.14.7 | MOLDURA DE CONCRETO EN PORTADA DE INGRESO INC. PINTADO | 1d | 2021-11-19 | 2021-11-19 | 200 | 5d | 0d |
| 202 | 1.2.14.8 | LETRAS DE ACERO INOXIDABLE EN PORTADA | 1d | 2021-11-20 | 2021-11-20 | 201 | 5d | 0d |
| 203 | 1.2.14.9 | BANCA DE CONCRETO (INC. ENCHAPE Y ACERO) | 2d | 2021-10-21 | 2021-10-22 | 149 | 36d |  |
| 204 | 1.2.14.10 | LIMPIEZA GENERAL DE LA OBRA | 2d | 2021-11-25 | 2021-11-26 | 298 | 1d |  |
| 205 | 1.2.15 | **SEGURIDAD** | 2d | 2021-11-21 | 2021-11-22 |  | 5d |  |
| 206 | 1.2.15.1 | SUMINISTRO E INSTALACION DE SEÑALES FOTLUMINISCENTES | 1d | 2021-11-21 | 2021-11-21 | 202 | 5d | 0d |
| 207 | 1.2.15.2 | SUMINISTRO E INSTALACION DE EXTINTOR DE PQS 6 KG | 1d | 2021-11-22 | 2021-11-22 | 206 | 5d |  |

| ID | WBS | Task | Duration | Start | Finish | Predecessors | Total slack | Free slack |
| --- | --- | --- | --- | --- | --- | --- | --- | --- |
| 208 | 1.3 | **INSTALACIONES SANITARIAS** | 121d | 2021-07-24 | 2021-11-21 |  | 6d |  |
| 209 | 1.3.1 | **ZAJAS PARA TUBERIAS** | 5d | 2021-07-24 | 2021-07-28 |  | 107d |  |
| 210 | 1.3.1.1 | EXCAVACION MANUAL PARA RED DE AGUA Y DESAGUE | 1d | 2021-07-24 | 2021-07-24 | 56 | 107d | 0d |
| 211 | 1.3.1.2 | REFINE Y NIVELACION DE ZANJAS | 1d | 2021-07-25 | 2021-07-25 | 210 | 122d | 0d |
| 212 | 1.3.1.3 | CAMA DE APOYO PARA TUBERIA | 1d | 2021-07-26 | 2021-07-26 | 211 | 122d | 0d |
| 213 | 1.3.1.4 | RELLENO Y COMPACTACION DE ZANJAS | 1d | 2021-07-27 | 2021-07-27 | 212 | 122d | 0d |
| 214 | 1.3.1.5 | ELIMINACION DE MATERIAL EXCEDENTE CON MAQUINARIA | 1d | 2021-07-28 | 2021-07-28 | 213 | 122d |  |
| 215 | 1.3.2 | **APARATOS SANITARIOS Y ACCESORIOS** | 17d | 2021-11-01 | 2021-11-17 |  | 10d |  |
| 216 | 1.3.2.1 | INODORO BABYFRESH CON ASIENTO BLANCO INC.ACCESORIOS | 1d | 2021-11-13 | 2021-11-13 | 160 | 10d | 0d |
| 217 | 1.3.2.2 | INODORO TANQUE BAJO CON GRIFERIA DE BRONCE | 1d | 2021-11-13 | 2021-11-13 | 216SS | 10d | 0d |
| 218 | 1.3.2.3 | URINARIO BAMBI BLANCO TREBOL INC. GRIFERIA | 2d | 2021-11-14 | 2021-11-15 | 217 | 10d | 0d |
| 219 | 1.3.2.4 | URINARIO DE LOSA BLANCO INC. GRIFERIA | 1d | 2021-11-14 | 2021-11-14 | 218SS | 10d | 0d |
| 220 | 1.3.2.5 | LAVATORIO VITRIFICADO BLANCO INC. GRIFERIA (BAÑO NIÑOS) | 2d | 2021-11-15 | 2021-11-16 | 219 | 10d | 0d |
| 221 | 1.3.2.6 | LAVATORIO VITRIFICADO BLANCO C/PEDESTAL INC. GRIFERIA (BAÑO PROF.) | 1d | 2021-11-15 | 2021-11-15 | 220SS | 10d | 0d |
| 222 | 1.3.2.7 | LAVADERO ACERO INOXIDABLE DE POZAS CON ESCURRIDERA | 1d | 2021-11-16 | 2021-11-16 | 221 | 11d |  |
| 223 | 1.3.2.8 | GRIFERIA PARA LAVATORIO | 2d | 2021-11-16 | 2021-11-17 | 221 | 10d |  |
| 224 | 1.3.2.9 | GRIFERIA PARA LAVADERO | 1d | 2021-11-17 | 2021-11-17 | 220 | 10d |  |
| 225 | 1.3.2.10 | PAPELERA LOSA COLOR | 2d | 2021-11-15 | 2021-11-16 | 221SS | 11d |  |
| 226 | 1.3.2.11 | SUMIDERO D=2'' | 3d | 2021-11-01 | 2021-11-03 | 140 | 23d | 0d |
| 227 | 1.3.2.12 | SUMIDERO D=4'' | 1d | 2021-11-04 | 2021-11-04 | 226 | 23d |  |
| 228 | 1.3.3 | **SISTEMA DE AGUA FRIA** | 17d | 2021-09-23 | 2021-10-09 |  | 49d |  |
| 229 | 1.3.3.1 | SALIDA DE AGUA FRIA CON TUBERIA PVC SAP 1/2'' | 5d | 2021-09-23 | 2021-09-27 | 115 | 49d | 0d |
| 230 | 1.3.3.2 | TUBERIA DE 1/2'' PVC SAP | 2d | 2021-09-28 | 2021-09-29 | 229 | 49d | 0d |
| 231 | 1.3.3.3 | TUBERIA DE 3/4'' PVC SAP | 1d | 2021-09-30 | 2021-09-30 | 230 | 49d | 0d |
| 232 | 1.3.3.4 | TUBERIA DE 1'' PVC SAP | 3d | 2021-10-01 | 2021-10-03 | 231 | 49d | 0d |
| 233 | 1.3.3.5 | VALVULA ESFERICA DE BRONCE 1/2" | 3d | 2021-10-04 | 2021-10-06 | 232 | 49d | 0d |
| 234 | 1.3.3.6 | NICHO PARA VALVULAS | 2d | 2021-10-07 | 2021-10-08 | 233 | 49d | 0d |
| 235 | 1.3.3.7 | PRUEBA HIDRAULICA + DESINFECCIÓN TUBERIA DE AGUA | 1d | 2021-10-09 | 2021-10-09 | 234 | 49d |  |

| ID | WBS | Task | Duration | Start | Finish | Predecessors | Total slack | Free slack |
| --- | --- | --- | --- | --- | --- | --- | --- | --- |
| 236 | 1.3.4 | **SISTEMA DE DESAGUE** | 101d | 2021-07-25 | 2021-11-02 |  | 25d |  |
| 237 | 1.3.4.1 | SALIDAS DE PVC SAL PARA DESAGUE 2'' | 5d | 2021-08-02 | 2021-08-06 | 242 | 107d | 0d |
| 238 | 1.3.4.2 | SALIDAS DE PVC SAL PARA DESAGUE 4'' | 3d | 2021-08-07 | 2021-08-09 | 237 | 107d | 0d |
| 239 | 1.3.4.3 | SALIDAS DE PVC SAL PARA VENTILACIÓN 2'' INC. SOMBRERO VENT. | 3d | 2021-08-10 | 2021-08-12 | 238 | 107d |  |
| 240 | 1.3.4.4 | TUBERIA PVC SAL 2'' | 4d | 2021-07-25 | 2021-07-28 | 210 | 107d | 0d |
| 241 | 1.3.4.5 | TUBERIA PVC SAL 4'' | 2d | 2021-07-29 | 2021-07-30 | 240 | 107d | 0d |
| 242 | 1.3.4.6 | TUBERIA PVC SAL 6'' | 2d | 2021-07-31 | 2021-08-01 | 241 | 107d | 0d |
| 243 | 1.3.4.7 | REGISTRO CROMADO D= 4" | 2d | 2021-11-01 | 2021-11-02 | 140 | 25d |  |
| 244 | 1.3.4.8 | CAJA DE REGISTRO DE 12''X24'' | 2d | 2021-07-31 | 2021-08-01 | 241 | 117d | 0d |
| 245 | 1.3.4.9 | PRUEBA HIDRAULICA + ESCORRENTIA DE TUB. DE DESAGUE | 1d | 2021-08-02 | 2021-08-02 | 244 | 117d |  |
| 246 | 1.3.5 | **CISTERNA Y TANQUE ELEVADO** | 10d | 2021-08-16 | 2021-08-25 |  | 94d |  |
| 247 | 1.3.5.1 | TUBERIA DE PVC - SAl D= 2'' - PARA REBOSE | 1d | 2021-08-16 | 2021-08-16 | 127 | 94d | 0d |
| 248 | 1.3.5.2 | TUBERIA DE IMPULSION F'G' D= 1'' | 1d | 2021-08-17 | 2021-08-17 | 247 | 94d | 0d |
| 249 | 1.3.5.3 | TUBERIA DE SUCCIÓN DE PVC-C10 D= 1'' | 1d | 2021-08-18 | 2021-08-18 | 248 | 94d | 0d |
| 250 | 1.3.5.4 | VALVULAS DE COMPUERTA DE BRONCE DE 1'' | 1d | 2021-08-19 | 2021-08-19 | 249 | 94d | 0d |
| 251 | 1.3.5.5 | VALVULAS CHECK DE BRONCE DE 1'' | 1d | 2021-08-20 | 2021-08-20 | 250 | 94d | 0d |
| 252 | 1.3.5.6 | VALVULAS CISTERNA Y TANQUE ELEVADO CON FLOTADOR DE 1'' | 1d | 2021-08-21 | 2021-08-21 | 251 | 94d | 0d |
| 253 | 1.3.5.7 | EQUIPO DE BOMBEO, ELECTROBOMBA DE 1HP | 2d | 2021-08-22 | 2021-08-23 | 252 | 94d | 0d |
| 254 | 1.3.5.8 | TANQUE DE POLIETILENO, CAP 1500L | 2d | 2021-08-24 | 2021-08-25 | 253 | 94d |  |
| 255 | 1.3.6 | **SISTEMA DE EVACUACIÓN PLUVIAL** | 51d | 2021-10-02 | 2021-11-21 |  | 6d |  |
| 256 | 1.3.6.1 | TUBERIA DE PVC SAL DE 4'' P/EVACUACIÓN PLUVIAL | 4d | 2021-10-02 | 2021-10-05 | 135 | 49d | 0d |
| 257 | 1.3.6.2 | TUBERIA DE PVC SAL DE 6'' P/EVACUACIÓN PLUVIAL | 1d | 2021-10-06 | 2021-10-06 | 256 | 51d | 0d |
| 258 | 1.3.6.3 | CODO DE 4''x90 GRADOS | 1d | 2021-10-07 | 2021-10-07 | 257 | 51d |  |
| 259 | 1.3.6.4 | CANALETA CONCRETO EN PISO F'C=175 KC/CM2 | 4d | 2021-10-21 | 2021-10-24 | 149 | 34d |  |
| 260 | 1.3.6.5 | REJILLA METALICA PARA CANALETA (INC. PINTURA) | 4d | 2021-11-18 | 2021-11-21 | 169 | 6d |  |
| 261 | 1.3.6.6 | FALSA COLUMNA DE CONCRETO P/MONTANTE Ø4'' 15X15 CM | 4d | 2021-10-06 | 2021-10-09 | 256 | 49d |  |

| ID | WBS | Task | Duration | Start | Finish | Predecessors | Total slack | Free slack |
| --- | --- | --- | --- | --- | --- | --- | --- | --- |
| 262 | 1.4 | **INSTALACIONES ELECTRICAS** | 127d | 2021-07-24 | 2021-11-27 |  | 0d |  |
| 263 | 1.4.1 | **OBRAS PRELIMINARES** | 3d | 2021-07-24 | 2021-07-26 |  | 124d |  |
| 264 | 1.4.1.1 | EXCAVACION DE ZANJAS PARA CABLES N2 X OH | 1d | 2021-07-24 | 2021-07-24 | 56 | 124d | 0d |
| 265 | 1.4.1.2 | SEÑALIZACION Y RELLENO CON MATERIAL PROPIO SELECCIONADO | 1d | 2021-07-25 | 2021-07-25 | 264 | 124d | 0d |
| 266 | 1.4.1.3 | ELIMINACIÓN DE MATERIAL EXCEDENTE CON MAQUINARIA | 1d | 2021-07-26 | 2021-07-26 | 265 | 124d |  |
| 267 | 1.4.2 | **SALIDAS PARA ALUMBRADO, TOMACORRIENTES, FUERZA, SEÑALES DÉBILES** | 19d | 2021-10-02 | 2021-10-20 |  | 37d |  |
| 268 | 1.4.2.1 | SALIDA PARA CENTRO DE LUZ P/EQ.ADOSADO | 6d | 2021-10-02 | 2021-10-07 | 135 | 37d | 0d |
| 269 | 1.4.2.2 | SALIDA PARA BRAQUETES | 3d | 2021-10-08 | 2021-10-10 | 268 | 37d | 0d |
| 270 | 1.4.2.3 | SALIDA PARA LUMINARIA DE EMERGENCIA ADOSADA EN PARED | 3d | 2021-10-11 | 2021-10-13 | 269 | 37d | 0d |
| 271 | 1.4.2.4 | SALIDA INTERRUPTOR SIMPLE | 3d | 2021-10-14 | 2021-10-16 | 270 | 38d | 0d |
| 272 | 1.4.2.5 | SALIDA INTERRUPTOR DOBLE | 1d | 2021-10-17 | 2021-10-17 | 271 | 38d | 0d |
| 273 | 1.4.2.6 | SALIDA INTERRUPTOR TRIPLE | 1d | 2021-10-18 | 2021-10-18 | 272 | 38d | 0d |
| 274 | 1.4.2.7 | SALIDA INTERRUPTOR DE CONMUTACIÓN SIMPLE | 1d | 2021-10-19 | 2021-10-19 | 273 | 38d | 0d |
| 275 | 1.4.2.8 | SALIDA INTERRUPTOR DE CONMUTACIÓN TRIPLE | 1d | 2021-10-20 | 2021-10-20 | 274 | 38d |  |
| 276 | 1.4.2.9 | SALIDA PARA TOMACORRIENTE DOBLE C/P.T. | 6d | 2021-10-06 | 2021-10-11 | 268SS+4d | 40d | 0d |
| 277 | 1.4.2.10 | SUM. INST. INTERRUPTOR SIMPLE | 4d | 2021-10-08 | 2021-10-11 | 268 | 42d | 0d |
| 278 | 1.4.2.11 | SUM. INST. INTERRUPTOR DOBLE | 1d | 2021-10-12 | 2021-10-12 | 277 | 42d | 0d |
| 279 | 1.4.2.12 | SUM. INST. INTERRUPTOR TRIPLE | 2d | 2021-10-13 | 2021-10-14 | 278 | 42d | 0d |
| 280 | 1.4.2.13 | SUM. INST. INTERRUPTOR CONMUTACIÓN SIMPLE | 1d | 2021-10-15 | 2021-10-15 | 279 | 42d | 0d |
| 281 | 1.4.2.14 | SUM. INST. INTERRUPTOR CONMUTACIÓN TRIPLE | 1d | 2021-10-16 | 2021-10-16 | 280 | 42d |  |
| 282 | 1.4.2.15 | SUM INST. TOMACORRIENTE DOBLE C/PT | 6d | 2021-10-12 | 2021-10-17 | 276 | 40d | 0d |
| 283 | 1.4.2.16 | SALIDA DEFUERZA PARA ELECTROBOMBAS DE 1 PTO HP | 1d | 2021-10-18 | 2021-10-18 | 282 | 40d |  |
| 284 | 1.4.3 | **CAJAS DE PASE** | 4d | 2021-09-25 | 2021-09-28 |  | 60d |  |
| 285 | 1.4.3.1 | CAJA DE PASE DE 100X100X50 mm | 1d | 2021-09-25 | 2021-09-25 | 289 | 60d | 0d |
| 286 | 1.4.3.2 | CAJA DE PASE DE METAL 400X300X200 mm | 1d | 2021-09-26 | 2021-09-26 | 285 | 60d | 0d |
| 287 | 1.4.3.3 | CAJA DE PASE DE 150X110X70 mm | 2d | 2021-09-27 | 2021-09-28 | 286 | 60d |  |

| ID | WBS | Task | Duration | Start | Finish | Predecessors | Total slack | Free slack |
| --- | --- | --- | --- | --- | --- | --- | --- | --- |
| 288 | 1.4.4 | **TABLEROS** | 6d | 2021-09-23 | 2021-09-28 |  | 53d |  |
| 289 | 1.4.4.1 | SUMINISTRO INST, TABLERO GENERAL TG TRES TRIFASICO 380-220 V(32 POLOS) | 2d | 2021-09-23 | 2021-09-24 | 115 | 53d | 0d |
| 290 | 1.4.4.2 | SUMINISTRO INST, TABLERO DE DIDTRIBUCIÓN STD -1,2,3 TRIFASICO 380-220 V(32 POLOS) | 3d | 2021-09-25 | 2021-09-27 | 289 | 53d | 0d |
| 291 | 1.4.4.3 | SUMINISTRO INST, TABLERO DE PARA ELECTROBOMBA TB MONOFASICO 220 V 1 HP | 1d | 2021-09-28 | 2021-09-28 | 290 | 53d | 0d |
| 292 | 1.4.5 | **ALIMENTADORES A TG, STDS Y CIRCUITOS DE FUERZAS** | 7d | 2021-09-29 | 2021-10-05 |  | 53d |  |
| 293 | 1.4.5.1 | CABLE N2XOH 3X25MM2(F)+1X6 MM 2(N) | 2d | 2021-09-29 | 2021-09-30 | 291 | 53d | 0d |
| 294 | 1.4.5.2 | CABLE NH-80 3X10MM2(F)+1X16MM2(N) | 1d | 2021-10-01 | 2021-10-01 | 293 | 53d | 0d |
| 295 | 1.4.5.3 | CABLE NH-80 1X6MM2(F)+1X16MM2(N)+ 1X6MM2(T) | 2d | 2021-10-02 | 2021-10-03 | 294 | 53d | 0d |
| 296 | 1.4.5.4 | CABLE NH-80 2X4MM2(F,N)+1X4MM2(T) | 2d | 2021-10-04 | 2021-10-05 | 295 | 53d |  |
| 297 | 1.4.6 | **ILUMINACIÓN** | 8d | 2021-11-20 | 2021-11-27 |  | 0d |  |
| 298 | 1.4.6.1 | SUM INST. LUMINARIA TIPO REJILLA ALUMINIZADA NACIONAL LED 2X18W | 5d | 2021-11-20 | 2021-11-24 | 190FS-3d | 0d |  |
| 299 | 1.4.6.2 | SUM INST. ARTEFACTO BRAQUETE, LUMINARIA TIPO JOSFEL RSP-2X36W | 3d | 2021-11-22 | 2021-11-24 | 298SS+2d | 0d |  |
| 300 | 1.4.6.3 | SUM INST. LUMINARIA PANEL LED 24W CIRCULAR LUZ FRIA (6500W) | 3d | 2021-11-25 | 2021-11-27 | 299 | 0d |  |
| 301 | 1.4.6.4 | SUM INST. LUMINARIA DE EMERGENCIA ADOSADA EN PARED | 2d | 2021-11-24 | 2021-11-25 | 300SS-1d | 2d |  |
| 302 | 1.4.7 | **POZO A TIERRA** | 7d | 2021-10-18 | 2021-10-24 |  | 34d |  |
| 303 | 1.4.7.1 | EXCAVACIÓN PARA POZO PUESTA A TIERRA | 2d | 2021-10-18 | 2021-10-19 | 149SS | 34d | 0d |
| 304 | 1.4.7.2 | PROTOCOLOS Y PRUEBAS ELECTRICAS | 2d | 2021-10-23 | 2021-10-24 | 305 | 34d |  |
| 305 | 1.4.7.3 | SUMINSTRO E INSTAL. DE PUESTA A TIERRA | 3d | 2021-10-20 | 2021-10-22 | 303 | 34d | 0d |
| 306 | 1.4.8 | **SISTEMA CABLEADO ESTRUCTURADO DE DATA (INTERNET)** | 8d | 2021-10-14 | 2021-10-21 |  | 37d |  |
| 307 | 1.4.8.1 | SALIDA PARA INTERNET | 2d | 2021-10-14 | 2021-10-15 | 270 | 37d | 0d |
| 308 | 1.4.8.2 | SALIDA PARA HDMI | 2d | 2021-10-16 | 2021-10-17 | 307 | 37d | 0d |
| 309 | 1.4.8.3 | SUMINISTRO PARA INTERNET-CABLE UTP CKT6 | 2d | 2021-10-18 | 2021-10-19 | 308 | 37d | 0d |
| 310 | 1.4.8.4 | SUMINISTRO PARA HDMI | 2d | 2021-10-20 | 2021-10-21 | 309 | 37d |  |
